# CAS Project v1.0 - 20110103

Schedule from MS Project, 2011-01-03 to 2011-04-04.

## Calendars

- Standard: Mon-Fri 08:00-12:00, 13:00-17:00; Sat-Sun off. Exceptions (off unless hours are given): 2011-01-20 (Thaipusom), 2011-02-01 (Federal day), 2011-02-03 to 2011-02-04 (CNY), 2011-02-15 (Nabi Mohomad Birtday).

## Schedule

| ID | WBS | Task | Duration | Start | Finish | Predecessors | Total slack | Free slack | Constraint |
| --- | --- | --- | --- | --- | --- | --- | --- | --- | --- |
| 1 | 1 | **CAS Project** | 60d | 2011-01-03 | 2011-04-04 |  | 0d |  |  |
| 2 | 1.1 | **Requirement Gathering** | 16d | 2011-01-03 | 2011-01-26 |  | 0d |  |  |
| 3 | 1.1.1 | Requirement Study | 5d | 2011-01-03 | 2011-01-10 |  | 0d |  |  |
| 4 | 1.1.2 | Requirement Compilation | 5d | 2011-01-10 | 2011-01-17 | 3 | 0d |  |  |
| 5 | 1.1.3 | Requirement Review | 5d | 2011-01-17 | 2011-01-25 | 4 | 0d |  |  |
| 6 | 1.1.4 | Requirement Sign Off | 1d | 2011-01-25 | 2011-01-26 | 5 | 0d |  |  |
| 7 | 1.2 | SIT/UAT Server Setup | 5d | 2011-01-17 | 2011-01-25 |  | 45d |  | start no earlier than 2011-01-17 |
| 8 | 1.3 | Production Server Setup | 5d | 2011-02-14 | 2011-02-22 |  | 29d |  | start no earlier than 2011-02-14 |
| 9 | 1.4 | **Development** | 23d | 2011-01-26 | 2011-03-04 |  | 0d |  |  |
| 10 | 1.4.1 | Customize CAS | 20d | 2011-01-26 | 2011-03-01 | 2 | 3d |  |  |
| 11 | 1.4.2 | CAS Admin Module | 20d | 2011-01-26 | 2011-03-01 | 2 | 0d |  |  |
| 12 | 1.4.3 | UAT Test Plan & Script | 3d | 2011-03-01 | 2011-03-04 | 11 | 0d |  | start no earlier than 2011-02-14 |
| 13 | 1.5 | UAT | 10d | 2011-03-04 | 2011-03-18 | 9 | 0d |  |  |
| 14 | 1.6 | UAT Sign Off | 1d | 2011-03-18 | 2011-03-21 | 13 | 0d |  |  |
| 15 | 1.7 | Perfomance Test | 10d | 2011-03-21 | 2011-04-04 | 14 | 0d |  |  |
| 16 | 1.8 | Training | 5d | 2011-03-18 | 2011-03-25 | 13 | 1d | 0d |  |
| 17 | 1.9 | Deployment To Production | 5d | 2011-03-25 | 2011-04-01 | 16 | 1d |  |  |
